# Hall D Offline Computing

Schedule from Planner, 2009-10-01 to 2012-05-18.

## Calendars

- Default: Mon-Fri 08:00-12:00, 13:00-17:00; Sat-Sun off.

## Resources

| Resource | Rate |
| --- | --- |
| Contributed |  |
| Scientist | 64.26 |

## Schedule

| ID | Task | Start | Finish | Predecessors | Resources | Work |
| --- | --- | --- | --- | --- | --- | --- |
| 1 | GEANT 4 Simulation [5533005] | 2009-10-01 | 2011-06-08 |  | Contributed | 3520h |
| 2 | MC Studies for Detector Optimization [5533010] | 2009-10-01 | 2011-01-05 |  | Contributed; Scientist | 5280h |
| 3 | Reconstruction Framework [5533015] | 2010-03-12 | 2011-01-13 | 2FS-7200h | Scientist | 1760h |
| 4 | Integration of Slow Controls [5533020] | 2011-01-14 | 2011-09-01 | 3 | Scientist | 1320h |
| 5 | DAQ to Detector Translation Table [5533025] | 2011-01-06 | 2011-11-09 | 2 | Contributed | 1760h |
| 6 | Micro DST Writer [5533030] | 2011-01-14 | 2011-06-16 | 3 | Contributed | 880h |
| 7 | CDC Reconstruction [5533035] | 2009-10-01 | 2010-05-19 |  | Contributed | 1320h |
| 8 | FDC Reconstruction [5533040] | 2009-10-01 | 2010-05-19 |  | Contributed | 1320h |
| 9 | Track Finding [5533045] | 2010-06-28 | 2011-09-30 | 3FS-4800h | Scientist | 2640h |
| 10 | Track Fitting [5533050] | 2010-06-28 | 2011-09-30 | 3FS-4800h | Scientist | 2640h |
| 11 | BCal Reconstruction [5533055] | 2010-06-28 | 2011-04-29 | 3FS-4800h | Contributed | 1760h |
| 12 | FCal Reconstruction [5533060] | 2010-06-28 | 2011-02-11 | 3FS-4800h | Contributed | 1320h |
| 13 | UPV Reconstruction [5533065] | 2009-10-01 | 2010-05-19 |  | Contributed | 1320h |
| 14 | TOF Reconstruction [5533070] | 2010-06-28 | 2011-02-11 | 3FS-4800h | Contributed | 1320h |
| 15 | Cherenkov Reconstruction [5533075] | 2009-10-01 | 2010-05-19 |  | Contributed | 1320h |
| 16 | Tagger Reconstruction [5533080] | 2010-06-28 | 2011-02-11 | 3FS-4800h | Contributed | 1320h |
| 17 | Start Counter Reconstruction [5533085] | 2010-06-28 | 2010-11-26 | 3FS-4800h | Contributed | 880h |
| 18 | Particle ID [5533090] | 2009-10-01 | 2010-08-04 |  | Contributed | 1760h |
| 19 | Kinematic Fitter [5533095] | 2009-10-01 | 2010-08-04 |  | Contributed | 1760h |
| 20 | Integration/QC [5533100] | 2010-06-28 | 2011-04-29 | 3FS-4800h | Scientist | 1760h |
| 21 | Calibration Database [5533105] | 2010-06-28 | 2010-11-26 | 3FS-4800h | Contributed [50%]; Scientist | 1320h |
| 22 | CDC Calibration [5533110] | 2009-10-01 | 2010-05-19 |  | Contributed | 1320h |
| 23 | FDC Calibration [5533115] | 2011-10-03 | 2012-05-18 | 10, 9 | Contributed | 1320h |
| 24 | BCal Calibration [5533120] | 2011-05-02 | 2011-12-16 | 11 | Contributed | 1320h |
| 25 | FCal Calibration [5533125] | 2011-02-14 | 2011-09-30 | 12 | Contributed | 1320h |
| 26 | UPV Calibration [5533130] | 2009-10-01 | 2010-05-19 |  | Contributed | 1320h |
| 27 | Cherenkov Calibration [5533135] | 2009-10-01 | 2010-05-19 |  | Contributed | 1320h |
| 28 | Tagger Calibration [5533140] | 2011-02-14 | 2011-09-30 | 16 | Contributed | 1320h |
| 29 | Starter Counter Calibration [5533145] | 2010-11-29 | 2011-04-29 | 17 | Contributed | 880h |
| 30 | Job Control Reconstruction [5533150] | 2009-10-01 | 2010-05-19 |  | Scientist | 1320h |
| 31 | Job Control/Database for Simulation [5533155] | 2009-10-01 | 2010-05-19 |  | Contributed | 1320h |
| 32 | PWA Development [5533160] | 2009-10-01 | 2010-03-03 |  | Contributed [500%]; Scientist | 5280h |
| 33 | PWA Challenge [5533165] | 2010-03-04 | 2010-08-04 | 32 | Contributed; Scientist | 1760h |
| 34 | Grid Implementation [5533170] | 2009-10-01 | 2009-12-16 |  | Contributed [300%]; Scientist | 1760h |
| 35 | Event Viewer (adapted from online) [5533175] | 2010-06-28 | 2010-11-26 | 3FS-4800h | Contributed | 880h |
| 36 | Documentation [5533180] | 2010-06-21 | 2011-04-22 | 2FS-4800h | Contributed; Scientist | 3520h |
