# Hall D Offline Computing

Schedule from Planner, 2009-10-01 to 2011-06-08.

## Calendars

- Default: Mon-Fri 08:00-12:00, 13:00-17:00; Sat-Sun off.

## Resources

| Resource | Rate |
| --- | --- |
| Contributed |  |
| Scientist | 66.31 |

## Schedule

| ID | Task | Start | Finish | Predecessors | Resources | Work |
| --- | --- | --- | --- | --- | --- | --- |
| 1 | MC Studies for Detector Optimization [5533010] | 2009-10-01 | 2010-04-16 |  | Contributed; Scientist | 2260h |
| 2 | Reconstruction Framework [5533015] | 2009-10-01 | 2010-02-10 | 1FS-7200h | Scientist | 753.2h |
| 3 | Integration of Slow Controls [5533020] | 2010-02-10 | 2010-09-29 | 2 | Scientist | 1320h |
| 4 | DAQ to Detector Translation Table [5533025] | 2010-04-16 | 2011-02-18 | 1 | Contributed | 1760h |
| 5 | Micro DST Writer [5533030] | 2010-02-10 | 2010-07-14 | 2 | Contributed | 880h |
| 6 | CDC Reconstruction [5533035] | 2009-10-01 | 2010-05-19 |  | Contributed | 1320h |
| 7 | FDC Reconstruction [5533040] | 2009-10-01 | 2010-05-19 |  | Contributed | 1320h |
| 8 | Track Finding [5533045] | 2009-10-01 | 2010-10-20 | 2FS-4800h | Scientist | 2199.2h |
| 9 | Track Fitting [5533050] | 2009-10-01 | 2010-10-20 | 2FS-4800h | Scientist | 2199.2h |
| 10 | BCal Reconstruction [5533055] | 2009-10-01 | 2010-08-04 | 2FS-4800h | Contributed | 1760h |
| 11 | FCal Reconstruction [5533060] | 2009-10-01 | 2010-05-19 | 2FS-4800h | Contributed | 1320h |
| 12 | TOF Reconstruction [5533070] | 2009-10-01 | 2010-05-19 | 2FS-4800h | Contributed | 1320h |
| 13 | Tagger Reconstruction [5533080] | 2009-10-01 | 2010-05-19 | 2FS-4800h | Contributed | 1320h |
| 14 | Start Counter Reconstruction [5533085] | 2009-10-01 | 2010-03-03 | 2FS-4800h | Contributed | 880h |
| 15 | Particle ID [5533090] | 2009-10-01 | 2010-08-04 |  | Contributed | 1760h |
| 16 | Kinematic Fitter [5533095] | 2009-10-01 | 2010-08-04 |  | Contributed | 1760h |
| 17 | Integration/QC [5533100] | 2009-10-01 | 2010-08-04 | 2FS-4800h | Scientist | 1760h |
| 18 | Calibration Database [5533105] | 2009-10-01 | 2010-03-03 | 2FS-4800h | Contributed [50%]; Scientist | 1320h |
| 19 | CDC Calibration [5533110] | 2009-10-01 | 2010-05-19 |  | Contributed | 1320h |
| 20 | FDC Calibration [5533115] | 2010-10-20 | 2011-06-08 | 9, 8 | Contributed | 1320h |
| 21 | BCal Calibration [5533120] | 2010-08-05 | 2011-03-23 | 10 | Contributed | 1320h |
| 22 | FCal Calibration [5533125] | 2010-05-20 | 2011-01-05 | 11 | Contributed | 1320h |
| 23 | UPV Calibration [5533130] | 2009-10-01 | 2010-05-19 |  | Contributed | 1320h |
| 24 | Cherenkov Calibration [5533135] | 2009-10-01 | 2010-05-19 |  | Contributed | 1320h |
| 25 | Tagger Calibration [5533140] | 2010-05-20 | 2011-01-05 | 13 | Contributed | 1320h |
| 26 | Starter Counter Calibration [5533145] | 2010-03-04 | 2010-08-04 | 14 | Contributed | 880h |
| 27 | Job Control Reconstruction [5533150] | 2009-10-01 | 2010-05-19 |  | Scientist | 1320h |
| 28 | Job Control/Database for Simulation [5533155] | 2009-10-01 | 2010-05-19 |  | Contributed | 1320h |
| 29 | PWA Development [5533160] | 2009-10-01 | 2010-03-03 |  | Contributed [500%]; Scientist | 5280h |
| 30 | PWA Challenge [5533165] | 2010-03-04 | 2010-08-04 | 29 | Contributed; Scientist | 1760h |
| 31 | Grid Implementation [5533170] | 2009-10-01 | 2009-12-16 |  | Contributed [300%]; Scientist | 1760h |
| 32 | Event Viewer (adapted from online) [5533175] | 2009-10-01 | 2010-03-03 | 2FS-4800h | Contributed | 880h |
| 33 | Documentation [5533180] | 2009-10-01 | 2010-08-04 | 1FS-4800h | Contributed; Scientist | 3520h |
