# Hall D Offline Computing

Schedule from Planner, 2009-10-01 to 2011-05-18.

## Calendars

- Default: Mon-Fri 08:00-12:00, 13:00-17:00; Sat-Sun off.

## Resources

| Resource | Rate |
| --- | --- |
| Contributed |  |
| Scientist | 66.31 |

## Schedule

| ID | Task | Start | Finish | Predecessors | Resources | Work |
| --- | --- | --- | --- | --- | --- | --- |
| 1 | MC Studies for Detector Optimization [5533010] | 2009-10-01 | 2010-04-16 |  | Contributed; Scientist | 2260h |
| 2 | Reconstruction Framework [5533015] | 2009-10-01 | 2010-02-10 | 1FS-7200h | Scientist | 753.2h |
| 3 | Integration of Slow Controls [5533020] | 2010-02-10 | 2010-09-29 | 2 | Scientist | 1320h |
| 4 | DAQ to Detector Translation Table [5533025] | 2010-04-16 | 2011-01-21 | 1 | Contributed; Scientist [10%] | 1760h |
| 5 | Micro DST Writer [5533030] | 2010-02-10 | 2010-06-30 | 2 | Contributed; Scientist [10%] | 880h |
| 6 | Track Finding [5533045] | 2009-10-01 | 2010-10-20 | 2FS-4800h | Scientist | 2199.2h |
| 7 | Track Fitting [5533050] | 2009-10-01 | 2010-10-20 | 2FS-4800h | Scientist | 2199.2h |
| 8 | BCal Reconstruction [5533055] | 2009-10-01 | 2010-07-07 | 2FS-4800h | Contributed; Scientist [10%] | 1760h |
| 9 | FCal Reconstruction [5533060] | 2009-10-01 | 2010-04-28 | 2FS-4800h | Contributed; Scientist [10%] | 1320h |
| 10 | TOF Reconstruction [5533070] | 2009-10-01 | 2010-04-28 | 2FS-4800h | Contributed; Scientist [10%] | 1320h |
| 11 | Tagger Reconstruction [5533080] | 2009-10-01 | 2010-04-28 | 2FS-4800h | Contributed; Scientist [10%] | 1320h |
| 12 | Start Counter Reconstruction [5533085] | 2009-10-01 | 2010-02-17 | 2FS-4800h | Contributed; Scientist [10%] | 880h |
| 13 | Particle ID [5533090] | 2009-10-01 | 2010-07-07 |  | Contributed; Scientist [10%] | 1760h |
| 14 | Kinematic Fitter [5533095] | 2009-10-01 | 2010-07-07 |  | Contributed; Scientist [10%] | 1760h |
| 15 | Integration/QC [5533100] | 2009-10-01 | 2010-08-04 | 2FS-4800h | Scientist | 1760h |
| 16 | Calibration Database [5533105] | 2009-10-01 | 2010-03-03 | 2FS-4800h | Contributed [50%]; Scientist | 1320h |
| 17 | CDC Calibration [5533110] | 2009-10-01 | 2010-04-28 |  | Contributed; Scientist [10%] | 1320h |
| 18 | FDC Calibration [5533115] | 2010-10-20 | 2011-05-18 | 7, 6 | Contributed; Scientist [10%] | 1320h |
| 19 | BCal Calibration [5533120] | 2010-07-08 | 2011-02-02 | 8 | Contributed; Scientist [10%] | 1320h |
| 20 | FCal Calibration [5533125] | 2010-04-29 | 2010-11-24 | 9 | Contributed; Scientist [10%] | 1320h |
| 21 | Tagger Calibration [5533140] | 2010-04-29 | 2010-11-24 | 11 | Contributed; Scientist [10%] | 1320h |
| 22 | Starter Counter Calibration [5533145] | 2010-02-18 | 2010-07-07 | 12 | Contributed; Scientist [10%] | 880h |
| 23 | Job Control Reconstruction [5533150] | 2009-10-01 | 2010-05-19 |  | Scientist | 1320h |
| 24 | Job Control/Database for Simulation [5533155] | 2009-10-01 | 2010-04-28 |  | Contributed; Scientist [10%] | 1320h |
| 25 | PWA Development [5533160] | 2009-10-01 | 2009-10-27 |  | Contributed [500%]; Scientist | 880h |
| 26 | PWA Challenge [5533165] | 2009-10-27 | 2009-11-03 | 25 | Contributed; Scientist | 80h |
| 27 | Grid Implementation [5533170] | 2009-10-01 | 2009-11-09 |  | Contributed [300%]; Scientist | 880h |
| 28 | Event Viewer (adapted from online) [5533175] | 2009-10-01 | 2010-03-03 | 2FS-4800h | Contributed | 880h |
| 29 | Documentation [5533180] | 2009-10-01 | 2009-12-16 | 1FS-4800h | Contributed; Scientist | 880h |
| 30 | TOF Calibration [5533200]? | 2009-10-01 | 2010-04-28 |  | Contributed; Scientist [10%] | 1320h |
| 31 | Coordination [5533205]? | 2009-10-01 | 2010-03-03 |  | Scientist | 880h |
